# Datová migrace Hubtex

Schedule from MS Project, 2007-01-15 to 2007-06-30, status date 2007-01-26, A marks actual dates.
GSC Beratung GmbH

## Calendars

- Standardní: Mon-Fri 09:00-12:15, 12:45-17:30; Sat-Sun off. Exceptions (off unless hours are given): 2007-04-09 (Velikonoční pondělí), 2007-05-01 (Svátek práce), 2007-05-08 (Den vítězství).
- Kalendář úkolu Načtení dat do "živého" systému: Mon-Fri 09:00-12:15, 12:45-17:30; Sat-Sun off. Exceptions (off unless hours are given): 2007-06-29 to 2007-06-30 08:00-20:00 (Ostrá migrace).
- Kalendář pracovní doba Hubtex: Mon-Fri 07:00-11:00, 11:30-15:30; Sat-Sun off. Exceptions (off unless hours are given): 2007-02-27 to 2007-02-28 (Rosenmontag (karneval)), 2007-04-13 (Velký pátek), 2007-04-15 (Velikonoční neděle), 2007-04-16 (Velikonoční pondělí), 2007-05-01 (Den práce), 2007-05-25 (Nanebevzetí Ježíše Krista), 2007-06-05 to 2007-06-06 (Letnice), 2007-06-15 (Boží tělo).

## Resources

| Resource | Unit | Rate |
| --- | --- | --- |
| Mirek Pala |  | 400 |
| Albert Höfer |  | 350 |
| Thomas König |  | 700 |
| zaměstnanec Schulte-Henke |  |  |
| osobní automobil BMW 523i | ks | 700 |
| osobní automobil Škoda Octavia RS | ks | 300 |
| diety | ks | 1260 |
| zaměstnanec Hubtex |  |  |

## Schedule

| ID | WBS | Task | Type | Duration | Start | Finish | Predecessors | Complete | Remaining | Baseline start | Baseline finish | Baseline duration | Total slack | Free slack | Constraint | Calendar |
| --- | --- | --- | --- | --- | --- | --- | --- | --- | --- | --- | --- | --- | --- | --- | --- | --- |
| 1 | 1 | Zahájení projektu | milestone | 0d | 2007-01-15 09:00 A | 2007-01-15 09:00 A |  | 100% |  | 2007-01-15 09:00 | 2007-01-15 09:00 | 0d |  |  |  |  |
| 2 | 2 | **Přípravná fáze** |  | 42d | 2007-01-15 09:00 A | 2007-03-13 17:30 |  | 21% | 33.38d | 2007-01-15 09:00 | 2007-03-14 14:00 | 42.56d | 75d |  |  |  |
| 3 | 2.1 | Příprava a kopírování dat do databáze Access |  | 2d | 2007-01-15 09:00 A | 2007-01-17 09:00 A | 1 | 100% |  | 2007-01-15 09:00 | 2007-01-17 09:00 | 2d |  |  |  | Kalendář pracovní doba Hubtex |
| 4 | 2.2 | Odeslání dat |  | 3d | 2007-01-17 09:00 A | 2007-01-19 17:30 A | 3 | 100% |  | 2007-01-17 09:00 | 2007-01-19 17:30 | 3d |  |  |  |  |
| 5 | 2.3 | Analýza struktury dat |  | 5d | 2007-01-22 09:00 A | 2007-01-26 17:30 A | 4 | 100% |  | 2007-01-22 09:00 | 2007-01-26 17:30 | 5d |  |  |  |  |
| 6 | 2.4 | Tvorba projektového plánu |  | 1d | 2007-01-29 09:00 | 2007-01-29 17:30 | 5 |  |  | 2007-01-29 09:00 | 2007-01-29 17:30 | 1d | 106d |  |  |  |
| 7 | 2.5 | Cesta Praha -> Fulda |  | 5eh | 2007-02-05 02:00 | 2007-02-05 07:00 | 8SF |  |  | 2007-02-05 04:00 | 2007-02-05 09:00 | 5eh | 436.57d |  |  |  |
| 8 | 2.6 | Osobní schůzka v Hubtexu |  | 2d | 2007-02-05 07:00 | 2007-02-06 15:30 | 5 |  |  | 2007-02-05 09:00 | 2007-02-07 09:00 | 2d | 49d | 0d | start no earlier than 2007-02-05 07:00 | Kalendář pracovní doba Hubtex |
| 9 | 2.7 | Cesta Fulda -> Praha |  | 5eh | 2007-02-06 15:30 | 2007-02-06 20:30 | 8 |  |  | 2007-02-07 09:00 | 2007-02-07 14:00 | 5eh | 226.81d | 1.56d |  |  |
| 10 | 2.8 | **Příprava dat a tabulek** |  | 3.38d | 2007-02-07 09:00 | 2007-02-12 12:00 |  |  |  | 2007-02-07 14:00 | 2007-02-12 17:00 | 3.38d | 52.24d |  |  |  |
| 11 | 2.8.1 | Číselník dílů |  | 6h | 2007-02-07 09:00 | 2007-02-07 15:30 | 9 |  |  | 2007-02-07 14:00 | 2007-02-08 11:30 | 6h | 52.24d | 0d |  |  |
| 12 | 2.8.2 | Zákazníci |  | 4h | 2007-02-07 15:30 | 2007-02-08 11:00 | 11 |  |  | 2007-02-08 11:30 | 2007-02-08 16:00 | 4h | 52.24d | 0d |  |  |
| 13 | 2.8.3 | Dodavatelé |  | 4h | 2007-02-08 11:00 | 2007-02-08 15:30 | 12 |  |  | 2007-02-08 16:00 | 2007-02-09 11:30 | 4h | 52.24d | 0d |  |  |
| 14 | 2.8.4 | Nákupní ceny |  | 2h | 2007-02-08 15:30 | 2007-02-08 17:30 | 13 |  |  | 2007-02-09 11:30 | 2007-02-09 14:00 | 2h | 52.24d | 0d |  |  |
| 15 | 2.8.5 | Prodejní ceny |  | 4h | 2007-02-09 09:00 | 2007-02-09 13:30 | 14 |  |  | 2007-02-09 14:00 | 2007-02-12 09:30 | 4h | 52.24d | 0d |  |  |
| 16 | 2.8.6 | Zakázky |  | 7h | 2007-02-09 13:30 | 2007-02-12 12:00 | 15 |  |  | 2007-02-12 09:30 | 2007-02-12 17:00 | 7h | 52.24d | 0d |  |  |
| 17 | 2.8.7 | Kusovníky |  | 3h | 2007-02-07 09:00 | 2007-02-07 12:00 | 11SS |  |  | 2007-02-07 14:00 | 2007-02-07 17:00 | 3h | 98.5d | 0d |  |  |
| 18 | 2.8.8 | Pracovní postupy |  | 5h | 2007-02-07 12:00 | 2007-02-07 17:30 | 17 |  |  | 2007-02-07 17:00 | 2007-02-08 14:00 | 5h | 98.5d | 0d |  |  |
| 19 | 2.8.9 | Objednávky |  | 4h | 2007-02-08 09:00 | 2007-02-08 13:30 | 18 |  |  | 2007-02-08 14:00 | 2007-02-09 09:30 | 4h | 98.5d |  |  |  |
| 20 | 2.9 | **Nastavení migračního programu** |  | 21.62d | 2007-02-12 12:00 | 2007-03-13 17:30 |  |  |  | 2007-02-12 17:00 | 2007-03-14 14:00 | 21.62d | 52.24d |  |  |  |
| 21 | 2.9.1 | Číselník dílů |  | 39h | 2007-02-12 12:00 | 2007-02-19 11:00 | 16 |  |  | 2007-02-12 17:00 | 2007-02-19 16:00 | 39h | 52.24d | 0d |  |  |
| 22 | 2.9.2 | Zákazníci |  | 28.5h | 2007-02-19 11:00 | 2007-02-22 16:00 | 21 |  |  | 2007-02-19 16:00 | 2007-02-23 12:00 | 28.5h | 52.24d | 0d |  |  |
| 23 | 2.9.3 | Dodavatelé |  | 28.5h | 2007-02-22 16:00 | 2007-02-28 12:00 | 22 |  |  | 2007-02-23 12:00 | 2007-02-28 17:00 | 28.5h | 52.24d | 0d |  |  |
| 24 | 2.9.4 | Nákupní ceny |  | 10h | 2007-02-28 12:00 | 2007-03-01 14:30 | 23 |  |  | 2007-02-28 17:00 | 2007-03-02 10:30 | 10h | 52.24d | 0d |  |  |
| 25 | 2.9.5 | Prodejní ceny |  | 23h | 2007-03-01 14:30 | 2007-03-06 13:30 | 24 |  |  | 2007-03-02 10:30 | 2007-03-07 09:30 | 23h | 52.24d | 0d |  |  |
| 26 | 2.9.6 | Zakázky |  | 44h | 2007-03-06 13:30 | 2007-03-13 17:30 | 25 |  |  | 2007-03-07 09:30 | 2007-03-14 14:00 | 44h | 52.24d | 0d |  |  |
| 27 | 2.9.7 | Kusovníky |  | 10h | 2007-02-12 12:00 | 2007-02-13 14:30 | 21SS |  |  | 2007-02-12 17:00 | 2007-02-14 10:30 | 10h | 88.62d | 0d |  |  |
| 28 | 2.9.8 | Pracovní postupy |  | 32h | 2007-02-13 14:30 | 2007-02-19 14:30 | 27 |  |  | 2007-02-14 10:30 | 2007-02-20 10:30 | 32h | 88.62d | 0d |  |  |
| 29 | 2.9.9 | Objednávky |  | 22h | 2007-02-19 14:30 | 2007-02-22 12:00 | 28 |  |  | 2007-02-20 10:30 | 2007-02-22 17:00 | 22h | 88.62d |  |  |  |
| 30 | 3 | Ukončení přípravné fáze | milestone | 0d | 2007-03-13 17:30 | 2007-03-13 17:30 | 26 |  |  | 2007-03-14 14:00 | 2007-03-14 14:00 | 0d | 52.24d | 0d |  |  |

| ID | WBS | Task | Type | Duration | Start | Finish | Predecessors | Baseline start | Baseline finish | Baseline duration | Total slack | Free slack | Constraint | Calendar |
| --- | --- | --- | --- | --- | --- | --- | --- | --- | --- | --- | --- | --- | --- | --- |
| 31 | 4 | **Testovací fáze** |  | 19.63d | 2007-03-14 09:00 | 2007-04-11 14:32 |  | 2007-03-14 14:00 | 2007-04-06 11:32 | 16.75d | 52.24d |  |  |  |
| 32 | 4.1 | **První testování** |  | 8.75d | 2007-03-14 09:00 | 2007-03-26 15:30 |  | 2007-03-14 14:00 | 2007-03-27 13:00 | 8.88d | 52.24d |  |  |  |
| 33 | 4.1.1 | **Načtení dat pro první testování** |  | 1.88d | 2007-03-14 09:00 | 2007-03-15 16:30 |  | 2007-03-14 14:00 | 2007-03-16 13:00 | 1.88d | 52.24d |  |  |  |
| 34 | 4.1.1.1 | Číselník dílů |  | 3h | 2007-03-14 09:00 | 2007-03-14 12:00 | 30 | 2007-03-14 14:00 | 2007-03-14 17:00 | 3h | 52.24d | 0d |  |  |
| 35 | 4.1.1.2 | Zákazníci |  | 1h | 2007-03-14 12:00 | 2007-03-14 13:30 | 34 | 2007-03-14 17:00 | 2007-03-15 09:30 | 1h | 73.62d | 0d |  |  |
| 36 | 4.1.1.3 | Dodavatelé |  | 1h | 2007-03-14 13:30 | 2007-03-14 14:30 | 35 | 2007-03-15 09:30 | 2007-03-15 10:30 | 1h | 73.62d | 0d |  |  |
| 37 | 4.1.1.4 | Nákupní ceny |  | 2h | 2007-03-14 14:30 | 2007-03-14 16:30 | 36 | 2007-03-15 10:30 | 2007-03-15 13:00 | 2h | 73.62d | 0d |  |  |
| 38 | 4.1.1.5 | Prodejní ceny |  | 1h | 2007-03-14 16:30 | 2007-03-14 17:30 | 37 | 2007-03-15 13:00 | 2007-03-15 14:00 | 1h | 73.62d | 0d |  |  |
| 39 | 4.1.1.6 | Zakázky |  | 3h | 2007-03-15 09:00 | 2007-03-15 12:00 | 38 | 2007-03-15 14:00 | 2007-03-15 17:00 | 3h | 73.62d |  |  |  |
| 40 | 4.1.1.7 | Kusovníky |  | 2h | 2007-03-14 12:00 | 2007-03-14 14:30 | 34 | 2007-03-14 17:00 | 2007-03-15 10:30 | 2h | 52.24d | 0d |  |  |
| 41 | 4.1.1.8 | Pracovní postupy |  | 8h | 2007-03-14 14:30 | 2007-03-15 14:30 | 40 | 2007-03-15 10:30 | 2007-03-16 10:30 | 8h | 52.24d | 0d |  |  |
| 42 | 4.1.1.9 | Objednávky |  | 2h | 2007-03-15 14:30 | 2007-03-15 16:30 | 41 | 2007-03-16 10:30 | 2007-03-16 13:00 | 2h | 52.24d | 0.12d |  |  |
| 43 | 4.1.2 | Testování načtených dat |  | 1w | 2007-03-16 07:00 | 2007-03-22 15:30 | 42 | 2007-03-16 13:00 | 2007-03-23 13:00 | 1w | 51.37d | 0d |  | Kalendář pracovní doba Hubtex |
| 44 | 4.1.3 | Úpravy a opravy po prvním testování |  | 2d | 2007-03-22 15:30 | 2007-03-26 15:30 | 43 | 2007-03-23 13:00 | 2007-03-27 13:00 | 2d | 54.37d | 0d |  |  |
| 45 | 4.2 | **Druhé testování** |  | 7.88d | 2007-03-26 15:30 | 2007-04-05 14:32 |  | 2007-03-27 13:00 | 2007-04-06 11:32 | 7.88d | 54.37d |  |  |  |
| 46 | 4.2.1 | Načtení dat pro druhé testování |  | 1.88d | 2007-03-26 15:30 | 2007-03-28 14:32 | 44 | 2007-03-27 13:00 | 2007-03-29 11:32 | 1.88d | 54.37d | 0d |  |  |
| 47 | 4.2.2 | Testování načtených dat |  | 1w | 2007-03-28 14:32 | 2007-04-04 14:32 | 46 | 2007-03-29 11:32 | 2007-04-05 11:32 | 1w | 50.37d | 0d |  | Kalendář pracovní doba Hubtex |
| 48 | 4.2.3 | Úpravy a opravy po druhém testování |  | 1d | 2007-04-04 14:32 | 2007-04-05 14:32 | 47 | 2007-04-05 11:32 | 2007-04-06 11:32 | 1d | 54.37d | 0d |  |  |
| 49 | 4.3 | Tvorba a kompletace dokumentace |  | 3d | 2007-04-05 14:32 | 2007-04-11 14:32 | 48 | 2007-04-06 11:32 | 2007-04-12 11:32 | 3d | 54.37d | 0d |  |  |
| 50 | 4.4 | Fakturace testovací fáze |  | 1h | 2007-04-05 14:32 | 2007-04-05 15:32 | 48 | 2007-04-06 11:32 | 2007-04-06 13:02 | 1h | 58.24d |  |  |  |
| 51 | 5 | Ukončení testovací fáze | milestone | 0d | 2007-04-11 14:32 | 2007-04-11 14:32 | 49 | 2007-04-06 11:32 | 2007-04-06 11:32 | 0d | 54.37d |  |  |  |
| 52 | 6 | **Ostrý provoz** |  | 2.32d | 2007-06-29 03:00 | 2007-06-30 14:32 |  | 2007-06-29 03:00 | 2007-06-30 14:32 | 2.32d | 0d |  |  | Kalendář úkolu Načtení dat do "živého" systému |
| 53 | 6.1 | Cesta Praha -> Fulda |  | 5eh | 2007-06-29 03:00 | 2007-06-29 08:00 | 54SF | 2007-06-29 03:00 | 2007-06-29 08:00 | 5eh | 4.44d |  |  |  |
| 54 | 6.2 | Obdržení aktuálních dat |  | 0.5h | 2007-06-29 08:00 | 2007-06-29 08:30 | 51 | 2007-06-29 08:00 | 2007-06-29 08:30 | 0.5h | 0d |  | start no earlier than 2007-06-29 07:00 | Kalendář úkolu Načtení dat do "živého" systému |
| 55 | 6.3 | Úprava nových dat |  | 3h | 2007-06-29 08:30 | 2007-06-29 11:30 | 54 | 2007-06-29 08:30 | 2007-06-29 11:30 | 3h | 0d |  |  | Kalendář úkolu Načtení dat do "živého" systému |
| 56 | 6.4 | Načtení dat do "živého" systému |  | 1.88d | 2007-06-29 11:30 | 2007-06-30 14:32 | 55 | 2007-06-29 11:30 | 2007-06-30 14:32 | 1.88d | 0d |  |  | Kalendář úkolu Načtení dat do "živého" systému |
| 57 | 7 | Uvedení do ostrého provozu | milestone | 0d | 2007-06-30 14:32 | 2007-06-30 14:32 | 56 | 2007-06-30 14:32 | 2007-06-30 14:32 | 0d | 0d |  |  |  |
| 58 | 8 | Cesta Fulda -> Praha |  | 5eh | 2007-06-30 14:32 | 2007-06-30 19:32 | 57 | 2007-06-30 14:32 | 2007-06-30 19:32 | 5eh | 0d |  |  |  |
| 59 | 9 | Fakturace uvedení dat do ostrého provozu |  | 1eh | 2007-06-30 14:32 | 2007-06-30 15:32 | 57 | 2007-06-30 14:32 | 2007-06-30 15:32 | 1eh | 0.5d |  |  |  |
| 60 | 10 | Ukončení projektu | milestone | 0d | 2007-06-30 19:32 | 2007-06-30 19:32 | 58 | 2007-06-30 19:32 | 2007-06-30 19:32 | 0d | 0d |  |  |  |
