# Datová migrace Hubtex

Schedule from MS Project, 2007-01-15 to 2007-06-30, status date 2007-01-30, costs in Kč, A marks actual dates.
GSC Beratung GmbH

## Calendars

- Standardní: Mon-Fri 09:00-12:15, 12:45-17:30; Sat-Sun off. Exceptions (off unless hours are given): 2007-04-09 (Velikonoční pondělí), 2007-05-01 (Svátek práce), 2007-05-08 (Den vítězství).
- Kalendář úkolu Načtení dat do "živého" systému: Mon-Fri 09:00-12:15, 12:45-17:30; Sat-Sun off. Exceptions (off unless hours are given): 2007-06-29 to 2007-06-30 08:00-20:00 (Ostrá migrace).
- Kalendář pracovní doba Hubtex: Mon-Fri 07:00-11:00, 11:30-15:30; Sat-Sun off. Exceptions (off unless hours are given): 2007-02-27 to 2007-02-28 (Rosenmontag (karneval)), 2007-04-13 (Velký pátek), 2007-04-15 (Velikonoční neděle), 2007-04-16 (Velikonoční pondělí), 2007-05-01 (Den práce), 2007-05-25 (Nanebevzetí Ježíše Krista), 2007-06-05 to 2007-06-06 (Letnice), 2007-06-15 (Boží tělo).

## Resources

| Resource | Unit | Rate | Cost per use |
| --- | --- | --- | --- |
| Mirek Pala |  | 400 |  |
| Albert Höfer |  | 350 |  |
| Thomas König |  | 700 |  |
| zaměstnanec Schulte-Henke |  |  |  |
| osobní automobil BMW 523i | km | 7 |  |
| osobní automobil Škoda Octavia RS | km | 2.5 |  |
| diety | ks | 1260 |  |
| zaměstnanec Hubtex |  |  |  |
| notebooky |  |  | 1750 |
| mobilní telefony |  |  | 466.67 |
| kanceláře Praha |  |  | 22400 |
| ADSL připojení k internetu |  |  | 1700 |
| CDMA připojení k internetu |  |  | 1400 |
| provize konzultantů |  |  | 28000 |
| hovorné |  |  | 5400 |

## Schedule

| ID | WBS | Task | Type | Duration | Start | Finish | Predecessors | Complete | Remaining | Total slack | Free slack | Constraint | Calendar | Resources | Work | Actual work | Cost | Actual cost |
| --- | --- | --- | --- | --- | --- | --- | --- | --- | --- | --- | --- | --- | --- | --- | --- | --- | --- | --- |
| 1 | 1 | Zahájení projektu | milestone | 0d | 2007-01-15 09:00 A | 2007-01-15 09:00 A |  | 100% |  |  |  |  |  |  |  |  |  |  |
| 2 | 2 | **Přípravná fáze** |  | 43.75d | 2007-01-15 09:00 A | 2007-03-15 15:30 |  | 22% | 34.16d | 73.25d |  |  |  |  | 457.2h | 57.2h | 157,920 | 14,500 |
| 3 | 2.1 | Příprava a kopírování dat do databáze Access |  | 2d | 2007-01-15 09:00 A | 2007-01-17 09:00 A | 1 | 100% |  |  |  |  | Kalendář pracovní doba Hubtex | zaměstnanec Schulte-Henke | 16h | 16h |  |  |
| 4 | 2.2 | Odeslání dat |  | 2.75d | 2007-01-17 09:00 A | 2007-01-19 17:30 A | 3 | 100% |  |  |  |  |  | zaměstnanec Schulte-Henke [5.5%] | 1.2h | 1.2h |  |  |
| 5 | 2.3 | Analýza struktury dat |  | 6.12d | 2007-01-22 09:00 A | 2007-01-30 13:30 A | 4 | 100% |  |  |  |  |  | Mirek Pala [25%]; Albert Höfer [75%] | 40h | 40h | 14,500 | 14,500 |
| 6 | 2.4 | Tvorba projektového plánu |  | 1d | 2007-01-30 13:30 | 2007-01-31 13:30 | 5 |  |  | 104.5d |  |  |  | Mirek Pala | 8h |  | 3,200 |  |
| 7 | 2.5 | Cesta Praha -> Fulda |  | 5eh | 2007-02-05 02:00 | 2007-02-05 07:00 | 8SF |  |  | 436.57d |  |  |  | Thomas König; Mirek Pala; osobní automobil Škoda Octavia RS [500 km] | 10h |  | 6,750 |  |
| 8 | 2.6 | Osobní schůzka v Hubtexu |  | 2d | 2007-02-05 07:00 | 2007-02-06 15:30 | 5 |  |  | 45d | 0d | start no earlier than 2007-02-05 07:00 | Kalendář pracovní doba Hubtex | Thomas König; Mirek Pala; zaměstnanec Hubtex [200%]; zaměstnanec Schulte-Henke [200%]; diety [2 ks] | 96h |  | 20,120 |  |
| 9 | 2.7 | Cesta Fulda -> Praha |  | 5eh | 2007-02-06 15:30 | 2007-02-06 20:30 | 8 |  |  | 206.37d | 1.56d |  |  | Thomas König; osobní automobil Škoda Octavia RS [500 km]; Mirek Pala | 10h |  | 6,750 |  |
| 10 | 2.8 | **Příprava dat a tabulek** |  | 3.62d | 2007-02-07 09:00 | 2007-02-12 14:30 |  |  |  | 47.74d |  |  |  |  | 39h |  | 15,000 |  |
| 11 | 2.8.1 | Číselník dílů |  | 6h | 2007-02-07 09:00 | 2007-02-07 15:30 | 9 |  |  | 47.74d | 0d |  |  | Mirek Pala | 6h |  | 2,400 |  |
| 12 | 2.8.2 | Zákazníci |  | 4h | 2007-02-07 15:30 | 2007-02-08 15:30 | 11 |  |  | 47.24d | 0d |  |  | Mirek Pala | 4h |  | 1,600 |  |
| 13 | 2.8.3 | Dodavatelé |  | 4h | 2007-02-08 15:30 | 2007-02-08 23:00 | 12 |  |  | 47.24d | 0d |  |  | Mirek Pala | 4h |  | 1,600 |  |
| 14 | 2.8.4 | Nákupní ceny |  | 2h | 2007-02-09 09:00 | 2007-02-09 11:00 | 13 |  |  | 47.49d | 0d |  |  | Mirek Pala | 2h |  | 800 |  |
| 15 | 2.8.5 | Prodejní ceny |  | 4h | 2007-02-09 11:00 | 2007-02-09 15:30 | 14 |  |  | 47.49d | 0d |  |  | Mirek Pala | 4h |  | 1,600 |  |
| 16 | 2.8.6 | Zakázky |  | 7h | 2007-02-09 15:30 | 2007-02-12 14:30 | 15 |  |  | 47.74d | 0d |  |  | Mirek Pala | 7h |  | 2,800 |  |
| 17 | 2.8.7 | Kusovníky |  | 3h | 2007-02-07 09:00 | 2007-02-07 12:00 | 11SS |  |  | 98.56d | 0d |  |  | Albert Höfer | 3h |  | 1,050 |  |
| 18 | 2.8.8 | Pracovní postupy |  | 5h | 2007-02-07 12:00 | 2007-02-07 17:30 | 17 |  |  | 98.5d | 0.56d |  |  | Albert Höfer | 5h |  | 1,750 |  |
| 19 | 2.8.9 | Objednávky |  | 4h | 2007-02-08 14:00 | 2007-02-08 18:00 | 18 |  |  | 97.94d |  |  |  | Albert Höfer | 4h |  | 1,400 |  |
| 20 | 2.9 | **Nastavení migračního programu** |  | 23.12d | 2007-02-12 14:30 | 2007-03-15 15:30 |  |  |  | 47.74d |  |  |  |  | 237h |  | 91,600 |  |
| 21 | 2.9.1 | Číselník dílů |  | 39h | 2007-02-12 14:30 | 2007-02-19 15:30 | 16 |  |  | 47.74d | 0d |  |  | Mirek Pala | 39h |  | 15,600 |  |
| 22 | 2.9.2 | Zákazníci |  | 28.5h | 2007-02-19 15:30 | 2007-02-23 14:00 | 21 |  |  | 47.74d | 0d |  |  | Mirek Pala | 28.5h |  | 11,400 |  |
| 23 | 2.9.3 | Dodavatelé |  | 28.5h | 2007-02-23 14:00 | 2007-03-01 14:30 | 22 |  |  | 47.49d | 0d |  |  | Mirek Pala | 28.5h |  | 11,400 |  |
| 24 | 2.9.4 | Nákupní ceny |  | 10h | 2007-03-01 14:30 | 2007-03-02 14:30 | 23 |  |  | 47.49d | 0d |  |  | Mirek Pala | 10h |  | 4,000 |  |
| 25 | 2.9.5 | Prodejní ceny |  | 23h | 2007-03-02 14:30 | 2007-03-07 13:30 | 24 |  |  | 47.74d | 0d |  |  | Mirek Pala | 23h |  | 9,200 |  |
| 26 | 2.9.6 | Zakázky |  | 44h | 2007-03-07 13:30 | 2007-03-15 15:30 | 25 |  |  | 47.49d | 0d |  |  | Mirek Pala | 44h |  | 17,600 |  |
| 27 | 2.9.7 | Kusovníky |  | 10h | 2007-02-12 14:30 | 2007-02-13 16:00 | 21SS |  |  | 86.94d | 0d |  |  | Albert Höfer | 10h |  | 3,500 |  |
| 28 | 2.9.8 | Pracovní postupy |  | 32h | 2007-02-13 16:00 | 2007-02-20 16:00 | 27 |  |  | 86.94d | 0d |  |  | Albert Höfer | 32h |  | 11,200 |  |
| 29 | 2.9.9 | Objednávky |  | 22h | 2007-02-20 16:00 | 2007-02-26 14:30 | 28 |  |  | 86.38d |  |  |  | Albert Höfer | 22h |  | 7,700 |  |
| 30 | 3 | Ukončení přípravné fáze | milestone | 0d | 2007-03-15 15:30 | 2007-03-15 15:30 | 26 |  |  | 47.49d | 0d |  |  |  |  |  |  |  |

Notes:
- 3: Diety: zaměstnanec Schulte-Henke / Vlastní zdroje GSC: zaměstnanec Schulte-Henke / Externí zdroje: zaměstnanec Schulte-Henke
- 4: Diety: zaměstnanec Schulte-Henke[5%] / Vlastní zdroje GSC: zaměstnanec Schulte-Henke[5%] / Externí zdroje: zaměstnanec Schulte-Henke[5%]
- 5: Diety: Mirek Pala[25%];Albert Höfer[75%] / Vlastní zdroje GSC: Mirek Pala[25%];Albert Höfer[75%] / Externí zdroje: Mirek Pala[25%];Albert Höfer[75%]
- 6: Diety: Mirek Pala / Vlastní zdroje GSC: Mirek Pala / Externí zdroje: Mirek Pala
- 7: Diety: Thomas König;Mirek Pala;osobní automobil Škoda Octavia RS[500 km] / Vlastní zdroje GSC: Thomas König;Mirek Pala;osobní automobil Škoda Octavia RS[500 km] / Externí zdroje: Thomas König;Mirek Pala;osobní automobil Škoda Octavia RS[500 km]
- 8: Diety: Thomas König;Mirek Pala;zaměstnanec Hubtex[200%];zaměstnanec Schulte-Henke[200%];diety[2 ks] / Vlastní zdroje GSC: Thomas König;Mirek Pala;zaměstnanec Hubtex[200%];zaměstnanec Schulte-Henke[200%];diety[2 ks] / Externí zdroje: Thomas König;Mirek Pala;zaměstnanec Hubtex[200%];zaměstnanec Schulte-Henke[200%];diety[2 ks]
- 9: Diety: Thomas König;osobní automobil Škoda Octavia RS[500 km];Mirek Pala / Vlastní zdroje GSC: Thomas König;osobní automobil Škoda Octavia RS[500 km];Mirek Pala / Externí zdroje: Thomas König;osobní automobil Škoda Octavia RS[500 km];Mirek Pala
- 11: Diety: Mirek Pala / Vlastní zdroje GSC: Mirek Pala / Externí zdroje: Mirek Pala
- 12: Diety: Mirek Pala / Vlastní zdroje GSC: Mirek Pala / Externí zdroje: Mirek Pala
- 13: Diety: Mirek Pala / Vlastní zdroje GSC: Mirek Pala / Externí zdroje: Mirek Pala
- 14: Diety: Mirek Pala / Vlastní zdroje GSC: Mirek Pala / Externí zdroje: Mirek Pala
- 15: Diety: Mirek Pala / Vlastní zdroje GSC: Mirek Pala / Externí zdroje: Mirek Pala
- 16: Diety: Mirek Pala / Vlastní zdroje GSC: Mirek Pala / Externí zdroje: Mirek Pala
- 17: Diety: Albert Höfer / Vlastní zdroje GSC: Albert Höfer / Externí zdroje: Albert Höfer
- 18: Diety: Albert Höfer / Vlastní zdroje GSC: Albert Höfer / Externí zdroje: Albert Höfer
- 19: Diety: Albert Höfer / Vlastní zdroje GSC: Albert Höfer / Externí zdroje: Albert Höfer
- 21: Diety: Mirek Pala / Vlastní zdroje GSC: Mirek Pala / Externí zdroje: Mirek Pala
- 22: Diety: Mirek Pala / Vlastní zdroje GSC: Mirek Pala / Externí zdroje: Mirek Pala
- 23: Diety: Mirek Pala / Vlastní zdroje GSC: Mirek Pala / Externí zdroje: Mirek Pala
- 24: Diety: Mirek Pala / Vlastní zdroje GSC: Mirek Pala / Externí zdroje: Mirek Pala
- 25: Diety: Mirek Pala / Vlastní zdroje GSC: Mirek Pala / Externí zdroje: Mirek Pala
- 26: Diety: Mirek Pala / Vlastní zdroje GSC: Mirek Pala / Externí zdroje: Mirek Pala
- 27: Diety: Albert Höfer / Vlastní zdroje GSC: Albert Höfer / Externí zdroje: Albert Höfer
- 28: Diety: Albert Höfer / Vlastní zdroje GSC: Albert Höfer / Externí zdroje: Albert Höfer
- 29: Diety: Albert Höfer / Vlastní zdroje GSC: Albert Höfer / Externí zdroje: Albert Höfer

| ID | WBS | Task | Type | Duration | Start | Finish | Predecessors | Total slack | Free slack | Constraint | Calendar | Resources | Work | Cost | Diety | Vlastní zdroje GSC | Externí zdroje |
| --- | --- | --- | --- | --- | --- | --- | --- | --- | --- | --- | --- | --- | --- | --- | --- | --- | --- |
| 31 | 4 | **Testovací fáze** |  | 21.06d | 2007-03-15 15:30 | 2007-04-16 16:00 |  | 47.49d |  |  |  |  | 374.08h | 50,980 |  |  |  |
| 32 | 4.1 | **První testování** |  | 9d | 2007-03-15 15:30 | 2007-03-28 15:30 |  | 47.49d |  |  |  |  | 175h | 20,600 |  |  |  |
| 33 | 4.1.1 | **Načtení dat pro první testování** |  | 2.25d | 2007-03-15 15:30 | 2007-03-19 18:00 |  | 47.49d |  |  |  |  | 23h | 8,600 |  |  |  |
| 34 | 4.1.1.1 | Číselník dílů |  | 3h | 2007-03-15 15:30 | 2007-03-15 22:00 | 30 | 47.49d | 0d |  |  | Mirek Pala | 3h | 1,200 | Mirek Pala | Mirek Pala | Mirek Pala |
| 35 | 4.1.1.2 | Zákazníci |  | 1h | 2007-03-15 22:00 | 2007-03-15 23:00 | 34 | 72d | 0d |  |  | Mirek Pala | 1h | 400 | Mirek Pala | Mirek Pala | Mirek Pala |
| 36 | 4.1.1.3 | Dodavatelé |  | 1h | 2007-03-16 09:00 | 2007-03-16 10:00 | 35 | 72.12d | 0d |  |  | Mirek Pala | 1h | 400 | Mirek Pala | Mirek Pala | Mirek Pala |
| 37 | 4.1.1.4 | Nákupní ceny |  | 2h | 2007-03-16 10:00 | 2007-03-16 12:00 | 36 | 72.12d | 0d |  |  | Mirek Pala | 2h | 800 | Mirek Pala | Mirek Pala | Mirek Pala |
| 38 | 4.1.1.5 | Prodejní ceny |  | 1h | 2007-03-16 12:00 | 2007-03-16 13:30 | 37 | 72.12d | 0d |  |  | Mirek Pala | 1h | 400 | Mirek Pala | Mirek Pala | Mirek Pala |
| 39 | 4.1.1.6 | Zakázky |  | 3h | 2007-03-16 13:30 | 2007-03-16 16:30 | 38 | 72.12d |  |  |  | Mirek Pala | 3h | 1,200 | Mirek Pala | Mirek Pala | Mirek Pala |
| 40 | 4.1.1.7 | Kusovníky |  | 2h | 2007-03-16 09:00 | 2007-03-16 11:00 | 34 | 47.62d | 0d |  |  | Albert Höfer | 2h | 700 | Albert Höfer | Albert Höfer | Albert Höfer |
| 41 | 4.1.1.8 | Pracovní postupy |  | 8h | 2007-03-16 11:00 | 2007-03-19 16:00 | 40 | 47.56d | 0d |  |  | Albert Höfer | 8h | 2,800 | Albert Höfer | Albert Höfer | Albert Höfer |
| 42 | 4.1.1.9 | Objednávky |  | 2h | 2007-03-19 16:00 | 2007-03-19 18:00 | 41 | 47.56d | 0d |  |  | Albert Höfer | 2h | 700 | Albert Höfer | Albert Höfer | Albert Höfer |
| 43 | 4.1.2 | Testování načtených dat |  | 1w | 2007-03-20 07:00 | 2007-03-26 15:30 | 42 | 46.87d | 0d |  | Kalendář pracovní doba Hubtex | zaměstnanec Schulte-Henke [200%]; zaměstnanec Hubtex | 120h |  | zaměstnanec Schulte-Henke[200%];zaměstnanec Hubtex | zaměstnanec Schulte-Henke[200%];zaměstnanec Hubtex | zaměstnanec Schulte-Henke[200%];zaměstnanec Hubtex |
| 44 | 4.1.3 | Úpravy a opravy po prvním testování |  | 2.06d | 2007-03-26 15:30 | 2007-03-28 15:30 | 43 | 49.87d | 0d |  |  | Mirek Pala; Albert Höfer | 32h | 12,000 | Mirek Pala;Albert Höfer | Mirek Pala;Albert Höfer | Mirek Pala;Albert Höfer |
| 45 | 4.2 | **Druhé testování** |  | 8d | 2007-03-28 15:30 | 2007-04-10 15:30 |  | 50.31d |  |  |  |  | 162.08h | 15,880 |  |  |  |
| 46 | 4.2.1 | Načtení dat pro druhé testování |  | 1.94d | 2007-03-28 15:30 | 2007-03-30 16:32 | 44 | 50.12d | 0.12d |  |  | Mirek Pala; Albert Höfer | 26.08h | 9,880 | Mirek Pala;Albert Höfer | Mirek Pala;Albert Höfer | Mirek Pala;Albert Höfer |
| 47 | 4.2.2 | Testování načtených dat |  | 1w | 2007-04-02 07:00 | 2007-04-06 15:30 | 46 | 47.25d | 0d |  | Kalendář pracovní doba Hubtex | zaměstnanec Schulte-Henke [200%]; zaměstnanec Hubtex | 120h |  | zaměstnanec Schulte-Henke[200%];zaměstnanec Hubtex | zaměstnanec Schulte-Henke[200%];zaměstnanec Hubtex | zaměstnanec Schulte-Henke[200%];zaměstnanec Hubtex |
| 48 | 4.2.3 | Úpravy a opravy po druhém testování |  | 1d | 2007-04-06 15:30 | 2007-04-10 15:30 | 47 | 51.25d | 0d |  |  | Mirek Pala; Albert Höfer | 16h | 6,000 | Mirek Pala;Albert Höfer | Mirek Pala;Albert Höfer | Mirek Pala;Albert Höfer |
| 49 | 4.3 | Tvorba a kompletace dokumentace |  | 3.31d | 2007-04-10 15:30 | 2007-04-16 16:00 | 48 | 51.19d | 0d |  |  | Mirek Pala; Albert Höfer [50%] | 36h | 13,800 | Mirek Pala;Albert Höfer[50%] | Mirek Pala;Albert Höfer[50%] | Mirek Pala;Albert Höfer[50%] |
| 50 | 4.4 | Fakturace testovací fáze |  | 1h | 2007-04-10 15:30 | 2007-04-10 16:30 | 48 | 56.12d |  |  |  | Thomas König | 1h | 700 | Thomas König | Thomas König | Thomas König |
| 51 | 5 | Ukončení testovací fáze | milestone | 0d | 2007-04-16 16:00 | 2007-04-16 16:00 | 49 | 51.19d |  |  |  |  |  |  |  |  |  |
| 52 | 6 | **Ostrý provoz** |  | 2.32d | 2007-06-29 03:00 | 2007-06-30 14:32 |  | 0d |  |  | Kalendář úkolu Načtení dat do "živého" systému |  | 49.08h | 26,195 |  |  |  |
| 53 | 6.1 | Cesta Praha -> Fulda |  | 5eh | 2007-06-29 03:00 | 2007-06-29 08:00 | 54SF | 4.44d |  |  |  | Mirek Pala; Albert Höfer; osobní automobil BMW 523i [500 km] | 10h | 7,250 | Mirek Pala;Albert Höfer;osobní automobil BMW 523i[500 km] | Mirek Pala;Albert Höfer;osobní automobil BMW 523i[500 km] | Mirek Pala;Albert Höfer;osobní automobil BMW 523i[500 km] |
| 54 | 6.2 | Obdržení aktuálních dat |  | 0.5h | 2007-06-29 08:00 | 2007-06-29 08:30 | 51 | 0d |  | start no earlier than 2007-06-29 07:00 | Kalendář úkolu Načtení dat do "živého" systému | Mirek Pala; Albert Höfer; zaměstnanec Hubtex | 1.5h | 375 | Mirek Pala;Albert Höfer;zaměstnanec Hubtex | Mirek Pala;Albert Höfer;zaměstnanec Hubtex | Mirek Pala;Albert Höfer;zaměstnanec Hubtex |
| 55 | 6.3 | Úprava nových dat |  | 3h | 2007-06-29 08:30 | 2007-06-29 11:30 | 54 | 0d |  |  | Kalendář úkolu Načtení dat do "živého" systému | Mirek Pala; Albert Höfer | 6h | 2,250 | Mirek Pala;Albert Höfer | Mirek Pala;Albert Höfer | Mirek Pala;Albert Höfer |
| 56 | 6.4 | Načtení dat do "živého" systému |  | 1.88d | 2007-06-29 11:30 | 2007-06-30 14:32 | 55 | 0d |  |  | Kalendář úkolu Načtení dat do "živého" systému | Mirek Pala; Albert Höfer; zaměstnanec Hubtex [10%]; diety [4 ks] | 31.58h | 16,320 | Mirek Pala;Albert Höfer;zaměstnanec Hubtex[10%];diety[4 ks] | Mirek Pala;Albert Höfer;zaměstnanec Hubtex[10%];diety[4 ks] | Mirek Pala;Albert Höfer;zaměstnanec Hubtex[10%];diety[4 ks] |
| 57 | 7 | Uvedení do ostrého provozu | milestone | 0d | 2007-06-30 14:32 | 2007-06-30 14:32 | 56 | 0d |  |  |  | provize konzultantů |  | 28,000 | provize konzultantů | provize konzultantů | provize konzultantů |
| 58 | 8 | Cesta Fulda -> Praha |  | 5eh | 2007-06-30 14:32 | 2007-06-30 19:32 | 57 | 0d |  |  |  | Mirek Pala; Albert Höfer; osobní automobil BMW 523i [500 km] | 10h | 7,250 | Mirek Pala;Albert Höfer;osobní automobil BMW 523i[500 km] | Mirek Pala;Albert Höfer;osobní automobil BMW 523i[500 km] | Mirek Pala;Albert Höfer;osobní automobil BMW 523i[500 km] |
| 59 | 9 | Fakturace uvedení dat do ostrého provozu |  | 1eh | 2007-06-30 14:32 | 2007-06-30 15:32 | 57 | 0.5d |  |  |  | Thomas König | 1h | 700 | Thomas König | Thomas König | Thomas König |
| 60 | 10 | Ukončení projektu | milestone | 0d | 2007-06-30 19:32 | 2007-06-30 19:32 | 58 | 0d |  |  |  |  |  |  |  |  |  |

| ID | WBS | Task | Type | Duration | Start | Finish | Total slack | Constraint | Resources | Cost |
| --- | --- | --- | --- | --- | --- | --- | --- | --- | --- | --- |
| 62 | 11 | **Zúčtování fixních nákladů** |  | 62d | 2007-01-31 09:00 | 2007-04-30 09:00 | 43d |  |  | 99,350.01 |
| 63 | 11.1 | Zúčtování fixních nákladů 1/2007 | milestone | 0d | 2007-01-31 09:00 | 2007-01-31 09:00 | 105d | start no earlier than 2007-01-31 09:00 | kanceláře Praha [50%]; ADSL připojení k internetu [50%]; CDMA připojení k internetu [50%]; hovorné [50%]; notebooky [50%]; mobilní telefony [50%] | 16,558.33 |
| 64 | 11.2 | Zúčtování fixních nákladů 2/2007 | milestone | 0d | 2007-02-28 09:00 | 2007-02-28 09:00 | 85d | start no earlier than 2007-02-28 09:00 | kanceláře Praha; ADSL připojení k internetu; CDMA připojení k internetu; hovorné; notebooky; mobilní telefony | 33,116.67 |
| 65 | 11.3 | Zúčtování fixních nákladů 3/2007 | milestone | 0d | 2007-03-31 09:00 | 2007-03-31 09:00 | 62d | start no earlier than 2007-03-31 09:00 | kanceláře Praha; ADSL připojení k internetu; CDMA připojení k internetu; hovorné; notebooky; mobilní telefony | 33,116.67 |
| 66 | 11.4 | Zúčtování fixních nákladů 4/2007 | milestone | 0d | 2007-04-30 09:00 | 2007-04-30 09:00 | 43d | start no earlier than 2007-04-30 09:00 | kanceláře Praha [50%]; ADSL připojení k internetu [50%]; CDMA připojení k internetu [50%]; hovorné [50%]; notebooky [50%]; mobilní telefony [50%] | 16,558.33 |

Notes:
- 63: Diety: kanceláře Praha[50%];ADSL připojení k internetu[50%];CDMA připojení k internetu[50%];hovorné[50%];notebooky[50%];mobilní telefony[50%] / Vlastní zdroje GSC: kanceláře Praha[50%];ADSL připojení k internetu[50%];CDMA připojení k internetu[50%];hovorné[50%];notebooky[50%];mobilní telefony[50%] / Externí zdroje: kanceláře Praha[50%];ADSL připojení k internetu[50%];CDMA připojení k internetu[50%];hovorné[50%];notebooky[50%];mobilní telefony[50%]
- 64: Diety: kanceláře Praha;ADSL připojení k internetu;CDMA připojení k internetu;hovorné;notebooky;mobilní telefony / Vlastní zdroje GSC: kanceláře Praha;ADSL připojení k internetu;CDMA připojení k internetu;hovorné;notebooky;mobilní telefony / Externí zdroje: kanceláře Praha;ADSL připojení k internetu;CDMA připojení k internetu;hovorné;notebooky;mobilní telefony
- 65: Diety: kanceláře Praha;ADSL připojení k internetu;CDMA připojení k internetu;hovorné;notebooky;mobilní telefony / Vlastní zdroje GSC: kanceláře Praha;ADSL připojení k internetu;CDMA připojení k internetu;hovorné;notebooky;mobilní telefony / Externí zdroje: kanceláře Praha;ADSL připojení k internetu;CDMA připojení k internetu;hovorné;notebooky;mobilní telefony
- 66: Diety: kanceláře Praha[50%];ADSL připojení k internetu[50%];CDMA připojení k internetu[50%];hovorné[50%];notebooky[50%];mobilní telefony[50%] / Vlastní zdroje GSC: kanceláře Praha[50%];ADSL připojení k internetu[50%];CDMA připojení k internetu[50%];hovorné[50%];notebooky[50%];mobilní telefony[50%] / Externí zdroje: kanceláře Praha[50%];ADSL připojení k internetu[50%];CDMA připojení k internetu[50%];hovorné[50%];notebooky[50%];mobilní telefony[50%]
